# B.1_project_plan

Schedule from MS Project, 2006-11-01 to 2011-11-02, A marks actual dates.

## Calendars

- Standard: Mon-Fri 08:00-12:00, 13:00-17:00; Sat-Sun off. Exceptions (off unless hours are given): 2008-11-01 08:00-12:00, 13:00-17:00, 2009-01-31 08:00-12:00, 13:00-17:00, 2009-10-31 08:00-12:00, 13:00-17:00, 2010-01-31 08:00-12:00, 13:00-17:00, 2010-07-31 08:00-12:00, 13:00-17:00, 2010-10-31 08:00-12:00, 13:00-17:00, 2011-04-30 08:00-12:00, 13:00-17:00, 2011-07-31 08:00-12:00, 13:00-17:00.

## Resources

| Resource |
| --- |
| ZLW |
| ZLW/SC |
| SC |
| WZL PS / WZL MQ / WZL TF / IPT 300 |
| (all) |

## Schedule

| ID | WBS | Task | Type | Duration | Start | Finish | Predecessors | Complete | Remaining | Total slack | Free slack | Constraint | Resources | Work | Actual work |
| --- | --- | --- | --- | --- | --- | --- | --- | --- | --- | --- | --- | --- | --- | --- | --- |
| 1 | 1 | Establishment of an evaluation questionnaire for B.2 |  | 66d? | 2006-11-01 A | 2007-01-31 |  | 95% | 3.3d? | 0d |  | finish no earlier than 2007-01-31 | ZLW/SC | 528h | 501.6h |
| 2 | 2 | B2 questinary | milestone | 0d | 2007-01-31 A | 2007-01-31 | 1 | 95% | 0d | 1248d |  | start no earlier than 2007-01-29 | WZL PS / WZL MQ / WZL TF / IPT 300 |  |  |
| 3 | 3 | Interviews with project partners about used simulation tools and their requirements |  | 771d? | 2007-01-31 A | 2010-01-08 |  | 12% | 678d? | 478d |  | start no earlier than 2007-01-31 | ZLW/SC | 6168h | 744h |
| 4 | 4 | Examination of the questionaire and preliminary prerequisites for the architecture |  | 100d? | 2007-05-14 A | 2007-09-28 |  | 20% | 80d? | 1076d | 0d | start no earlier than 2007-05-14 | ZLW/SC | 800h | 160h |
| 5 | 5 | First questionnaire evaluation completed | milestone | 0d | 2007-09-28 | 2007-09-28 | 4 |  |  | 1076d |  |  |  |  |  |
| 7 | 6 | **automating a partially closed process-chain for a B2 Use Case** |  | 180d? | 2007-04-16 A | 2007-12-21 |  | 7% | 167.52d? | 1016d |  |  | ZLW/SC | 4720h | 379.8h |
| 8 | 6.1 | query, analysis, and description of process-chains and appropriate models/tools |  | 180d | 2007-04-16 A | 2007-12-21 |  | 19% | 145d | 1016d |  | start no earlier than 2007-04-16 | ZLW/SC | 1440h | 280h |
| 9 | 6.2 | Analysis of the intra process-chain information flow |  | 95d? | 2007-05-21 | 2007-09-28 |  |  |  | 1076d |  | start no earlier than 2007-05-21 |  |  |  |
| 10 | 6.3 | transfer of informations from process to data level |  | 90d | 2007-06-18 | 2007-10-19 |  |  |  | 1061d |  | start no earlier than 2007-06-18 | ZLW | 720h |  |
| 11 | 6.4 | modelling an extensible interface for the selected subprocess-chain |  | 85d | 2007-08-13 | 2007-12-07 |  |  |  | 1026d |  | start no earlier than 2007-08-13 | ZLW/SC | 680h |  |
| 12 | 6.5 | automate selected process chains as isolated application / proof of concept |  | 55d? | 2007-10-08 | 2007-12-21 |  |  |  | 1016d |  | finish no earlier than 2007-12-21 | SC | 440h |  |
| 16 | 7 | Adaptation of the first questionnaire |  | 30d | 2007-07-16 | 2007-08-24 |  |  |  | 1001d | 0d | start no earlier than 2007-07-16 | ZLW/SC | 240h |  |
| 17 | 8 | Second round of evaluation and interviews with project partners |  | 100d? | 2007-08-27 | 2008-01-11 | 16 |  |  | 1001d | 0d |  | ZLW/SC | 800h |  |
| 18 | 9 | Evaluation completed | milestone | 0d | 2008-01-11 | 2008-01-11 | 17 |  |  | 1001d |  |  |  |  |  |
| 19 | 10 | Preliminary Software architecture |  | 100d? | 2007-07-16 | 2007-11-30 |  |  |  | 1031d |  | start no earlier than 2007-07-16 | ZLW | 800h |  |
| 20 | 11 | Examination of requirements for the grid architecture |  | 145d | 2007-04-16 A | 2007-11-02 |  | 17% | 120d | 1051d |  | start no earlier than 2007-04-16 | SC | 1160h | 200h |
| 21 | 12 | Categorisation of requirements of the used simulation tools |  | 70d | 2007-09-17 | 2007-12-21 |  |  |  | 1016d |  | start no earlier than 2007-09-15 | ZLW | 560h |  |
| 22 | 13 | Concepts for a generic intermediate data format and its interfacing mechanisms |  | 120d? | 2007-06-15 | 2007-11-29 |  |  |  | 1032d | 0d | start no earlier than 2007-06-15 | ZLW/SC | 960h |  |
| 23 | 14 | Definition of concepts for data format completed | milestone | 0d | 2007-11-29 | 2007-11-29 | 22 |  |  | 1032d |  |  |  |  |  |
| 24 | 15 | Preliminary work for data translator |  | 145d? | 2007-07-16 | 2008-02-01 |  |  |  | 986d |  | start no earlier than 2007-07-16 | ZLW | 1160h |  |
| 25 | 16 | Research in state of the art of modeling data translators |  | 70d? | 2007-06-04 | 2007-09-07 |  |  |  | 936d | 15d | start no earlier than 2007-06-04 | ZLW/SC | 560h |  |
| 26 | 17 | Extended data format considering input parameters and scoring functions |  | 155d? | 2007-10-01 | 2008-05-02 | 25 |  |  | 921d | 0d | start no earlier than 2007-10-01 | SC | 1240h |  |
| 27 | 18 | first prototype of data format | milestone | 0d | 2008-05-02 | 2008-05-02 | 26 |  |  | 921d |  |  |  |  |  |
| 28 | 19 | implementation efforts towards a first concept demonstrator / mock up |  | 180d? | 2008-01-28 | 2008-10-03 |  |  |  | 811d |  | start no earlier than 2008-01-28 |  |  |  |
| 29 | 20 | proof of concept with mock up system |  | 66d? | 2008-08-01 | 2008-10-31 |  |  |  | 791d |  | finish no earlier than 2008-10-31 |  |  |  |
| 30 | 21 | interface and data handling workshops with partners from B.2 |  | 66d? | 2008-09-01 | 2008-11-28 |  |  |  | 770d |  | start no earlier than 2008-09-01 |  |  |  |
| 31 | 22 | rudimentary implementation of adapted optimization routines using parameters and scoring mechanisms for inverse modelling |  | 64d? | 2008-10-06 | 2008-12-31 |  |  |  | 747d |  | start no earlier than 2008-10-06 |  |  |  |
| 32 | 23 | supporting end user activities for partners in B.2 regarding the coupling with the software platform from B.1 / single simulator integration |  | 132d? | 2008-10-06 | 2009-04-03 |  |  |  | 679d |  | start no earlier than 2008-10-06 |  |  |  |
| 33 | 24 | post processing and requirements for final mock up and VR Visualisation |  | 227d? | 2008-12-29 | 2009-11-06 |  |  |  | 523d |  | start no earlier than 2008-12-29 |  |  |  |
| 34 | 25 | adaptations in collaboration with B.2 |  | 162d? | 2009-06-29 | 2010-02-05 |  |  |  | 457d |  | start no earlier than 2009-06-29 |  |  |  |
| 35 | 26 | refinments in collaboration with partners from B.2 |  | 162d? | 2009-09-28 | 2010-05-07 |  |  |  | 392d |  | start no earlier than 2009-09-28 |  |  |  |
| 36 | 27 | user interface for for visualisation platfrom and steering of content management |  | 65d? | 2010-05-04 | 2010-07-31 |  |  |  | 331d |  | finish no earlier than 2010-07-31 |  |  |  |
| 37 | 28 | extended user interface for higher oder functionalities like inverse capabilities |  | 152d? | 2009-11-02 | 2010-05-31 |  |  |  | 376d |  | start no earlier than 2009-11-02 |  |  |  |
| 38 | 29 | B.2 use case driven adaptations for demonstrators |  | 202d? | 2010-05-03 | 2011-02-04 |  |  |  | 195d |  | start no earlier than 2010-05-03 |  |  |  |
| 39 | 30 | refining work concerning technology demonstrators |  | 162d? | 2010-09-27 | 2011-05-06 |  |  |  | 129d |  | start no earlier than 2010-09-27 |  |  |  |
| 40 | 31 | final demonstrator targeted implementing and testing |  | 197d? | 2011-01-31 | 2011-10-28 |  |  |  | 3d |  | start no earlier than 2011-01-31 |  |  |  |
| 41 | 32 | technology demonstrators for B | milestone | 0d | 2011-10-31 | 2011-10-31 |  |  |  | 2d |  | finish no earlier than 2011-10-31 |  |  |  |
| 42 | 33 | Definition of a holistic process map of production |  | 66d | 2006-11-01 A | 2007-01-31 |  | 95% | 3.3d | 0d |  | start no earlier than 2006-11-01 | WZL PS / WZL MQ / WZL TF / IPT 300 | 528h | 501.6h |
| 43 | 34 | Process map of production | milestone | 0d | 2007-01-31 A | 2007-01-31 | 42 | 95% | 0d | 1248d |  |  | WZL PS / WZL MQ / WZL TF / IPT 300 |  |  |
| 44 | 35 | Identification of state-of-the-art simulation models (external and within the excellence cluster) |  | 75d | 2006-12-18 | 2007-03-30 |  |  |  | 1206d | 0d | finish no earlier than 2007-03-30 | WZL PS / WZL MQ / WZL TF / IPT 300 | 600h |  |
| 45 | 36 | Process map filled with models first | milestone | 0d | 2007-03-30 | 2007-03-30 | 44 |  |  | 1206d |  |  | WZL PS / WZL MQ / WZL TF / IPT 300 |  |  |
| 46 | 37 | Identification of outputs and necessary inputs for all models (from processes, from other models and from external influenes) |  | 87d | 2007-03-01 | 2007-06-29 |  |  |  | 1141d | 0d | finish no earlier than 2007-06-29 | WZL PS / WZL MQ / WZL TF / IPT 300 | 696h |  |
| 47 | 38 | Inputs and outputs for all models | milestone | 0d | 2007-06-29 | 2007-06-29 | 46 |  |  | 1141d |  |  | WZL PS / WZL MQ / WZL TF / IPT 300 |  |  |

Notes:
- 1: Questionary prototype on BSCW Server
- 3: Questionaire and first queries on BSCW
- 42: Process map on BSCW server

| ID | WBS | Task | Type | Duration | Start | Finish | Predecessors | Total slack | Free slack | Constraint | Resources | Work |
| --- | --- | --- | --- | --- | --- | --- | --- | --- | --- | --- | --- | --- |
| 48 | 39 | **Identification of critical model parameters for stable information exchange** |  | 105d | 2007-06-18 | 2007-11-09 |  | 728d |  |  | WZL PS / WZL MQ / WZL TF / IPT 300 | 2024h |
| 49 | 39.1 | Definition of correlations between models and their in- & outputs |  | 55d | 2007-06-18 | 2007-08-31 |  | 1046d | 0d | finish no earlier than 2007-08-31 | WZL PS / WZL MQ / WZL TF / IPT 300 | 440h |
| 50 | 39.2 | Correlation matrix | milestone | 0d | 2007-08-31 | 2007-08-31 | 49 | 1046d | 0d |  | WZL PS / WZL MQ / WZL TF / IPT 300 |  |
| 51 | 39.3 | Identification of correlation gaps and deficits concerning data quality, missing correlations and missing models |  | 50d | 2007-09-03 | 2007-11-09 | 50 | 1046d | 0d | finish no earlier than 2007-10-31 | WZL PS / WZL MQ / WZL TF / IPT 300 | 400h |
| 52 | 39.4 | Gap-matrix | milestone | 0d | 2007-11-09 | 2007-11-09 | 51 | 1046d |  |  | WZL PS / WZL MQ / WZL TF / IPT 300 |  |
| 53 | 39.5 | Detailed specification of requirements for WP A.2 |  | 43d | 2007-09-03 | 2007-10-31 |  | 673d | 0d | start no earlier than 2007-09-03 | WZL PS / WZL MQ / WZL TF / IPT 300 | 344h |
| 54 | 40 | **A.2 Semantic Connectivity for specific sub-models** |  | 180d | 2007-11-01 | 2008-07-09 | 53 | 673d | 62d |  | WZL PS / WZL MQ / WZL TF / IPT 300 | 4320h |
| 55 | 40.1 | Product, manufacturing process, material (WZL-TF) |  | 180d | 2007-11-01 | 2008-07-09 |  | 673d |  | start no earlier than 2007-10-01 | WZL PS / WZL MQ / WZL TF / IPT 300 | 1440h |
| 56 | 40.2 | Logistics, factory design, product (WZL-PS) |  | 180d | 2007-11-01 | 2008-07-09 |  | 673d |  | start no earlier than 2007-10-01 | WZL PS / WZL MQ / WZL TF / IPT 300 | 1440h |
| 57 | 41 | **Specification of information needs to cover the functional interdependencies** |  | 261d | 2008-10-06 | 2009-10-01 | 54 | 550d |  |  |  |  |
| 58 | 41.1 | Framework for information exchange between sub-models |  | 150d | 2008-10-06 | 2009-04-29 |  | 661d |  | start no earlier than 2008-10-06 |  |  |
| 59 | 41.2 | Criteria to ensure disjunctive transfer of information between sub-models |  | 200d | 2008-12-29 | 2009-10-01 |  | 550d |  | start no earlier than 2008-12-29 |  |  |
| 60 | 42 | Definition of necessary information flow between sub-models |  | 180d | 2009-06-29 | 2010-03-03 |  | 439d |  | start no earlier than 2009-06-29 |  |  |
| 61 | 43 | Requirements specification for translators and information models |  | 150d | 2009-09-28 | 2010-04-21 |  | 204d | 0d | start no earlier than 2009-09-28 |  |  |
| 62 | 44 | **A.3 Development of entire model map for information exchange** |  | 404d | 2010-04-22 | 2011-11-02 | 61 | 0d |  |  |  |  |
| 63 | 44.1 | Development of translators and information exchange models |  | 170d | 2010-04-22 | 2010-12-13 |  | 234d |  | start no earlier than 2009-11-02 |  |  |
| 64 | 44.2 | Information transfer functions |  | 140d | 2010-05-03 | 2010-11-10 |  | 257d |  | start no earlier than 2010-05-03 |  |  |
| 65 | 44.3 | Development of standards for an integrated quality assessment of product and manufacturing process characteristics regarding simulations as well as required supplementing information (WZL-MQ) |  | 200d | 2010-09-27 | 2011-06-29 |  | 91d |  | start no earlier than 2010-09-27 |  |  |
| 66 | 44.4 | Controlling mechanisms to ensure destinct allocation of required and perceived information between the semantic sub-models (IPT 300) |  | 200d | 2011-01-31 | 2011-11-02 |  | 0d |  | start no earlier than 2011-01-31 |  |  |
